# planning APD ind A

Schedule from MS Project, 2026-11-30 to 2027-11-18, 7 hours a day.

## Calendars

- Standard avec congé: Mon-Fri 09:00-12:00, 14:00-18:00; Sat-Sun off. Exceptions (off unless hours are given): 2026-12-18 to 2027-01-04 (HIVER).

## Schedule

| ID | WBS | Task | Type | Duration | Start | Finish | Predecessors | Total slack | Free slack | Constraint |
| --- | --- | --- | --- | --- | --- | --- | --- | --- | --- | --- |
| 1 | 1 | **CMG AMIENS** |  | 242d | 2026-11-30 | 2027-11-18 |  | 0d |  |  |
| 2 | 1.1 | **Travaux préparatoires OS** |  | 66d | 2026-11-30 | 2027-03-17 |  | 0d |  |  |
| 3 | 1.1.1 | Réseaux pour cuisine provisoire |  | 10d | 2026-11-30 | 2026-12-11 |  | 241d | 0d | start no earlier than 2026-11-30 |
| 4 | 1.1.2 | Fondations provisoires |  | 15d | 2026-12-14 | 2027-01-19 | 3 | 241d | 0d |  |
| 5 | 1.1.3 | dévoiement des réseaux existant sous extension |  | 10d | 2027-01-20 | 2027-02-02 | 4 | 241d |  | start no earlier than 2026-11-30 |
| 6 | 1.1.4 | Construction aménagement cuisine provisoire |  | 45d | 2026-11-30 | 2027-02-16 |  | 0d |  | start no earlier than 2026-11-30 |
| 7 | 1.1.5 | installation cuisine provisoire |  | 21d | 2027-02-17 | 2027-03-17 | 6 | 0d |  |  |
| 8 | 1.2 | **Travaux dans existant** |  | 75d | 2027-03-18 | 2027-06-30 |  | 0d |  |  |
| 9 | 1.2.1 | purge cuisine existante |  | 15d | 2027-03-18 | 2027-04-07 | 7 | 125d | 0d |  |
| 10 | 1.2.2 | désamiantage zone carrellage |  | 21d | 2027-03-18 | 2027-04-15 | 7 | 186d | 0d |  |
| 11 | 1.2.3 | dépose faux plafond zone salle a manger |  | 3d | 2027-04-16 | 2027-04-20 | 10 | 186d |  |  |
| 12 | 1.2.4 | démolition escalier |  | 5d | 2027-03-18 | 2027-03-24 | 7 | 0d |  |  |
| 13 | 1.2.5 | Percement cuisine existante |  | 10d | 2027-04-08 | 2027-04-21 | 9 | 125d | 0d |  |
| 14 | 1.2.6 | Cloisons sandwich | manual | 15d | 2027-04-22 | 2027-05-12 | 13 |  |  |  |
| 15 | 1.2.7 | Plancher salle a mangé |  | 30d | 2027-03-18 | 2027-04-28 | 7 | 65d | 0d |  |
| 16 | 1.2.8 | CVC |  | 50d | 2027-04-22 | 2027-06-30 | 13 | 101d |  |  |
| 17 | 1.2.9 | CFO CFA |  | 50d | 2027-04-22 | 2027-06-30 | 13 | 101d |  |  |
| 18 | 1.2.10 | Menuiseries éxtérieures salla à manger |  | 10d | 2027-04-29 | 2027-05-12 | 15 | 136d |  |  |
| 19 | 1.2.11 | carrellage |  | 30d | 2027-04-29 | 2027-06-09 | 15 | 65d | 0d |  |
| 20 | 1.3 | **extension cuisine** |  | 80d | 2027-03-25 | 2027-07-14 |  | 0d |  |  |
| 21 | 1.3.1 | terrassement |  | 2d | 2027-03-25 | 2027-03-26 | 12 | 0d |  |  |
| 22 | 1.3.2 | Micropieux |  | 9d | 2027-03-31 | 2027-04-12 | 7, 35 | 0d |  |  |
| 23 | 1.3.3 | recépage |  | 2d | 2027-04-13 | 2027-04-14 | 22 | 0d |  |  |
| 24 | 1.3.4 | Longrine y compris laverie |  | 15d | 2027-04-15 | 2027-05-05 | 23 | 0d |  |  |
| 25 | 1.3.5 | poteaux rdj |  | 5d | 2027-05-06 | 2027-05-12 | 24 | 45d | 0d |  |
| 26 | 1.3.6 | Poutres |  | 5d | 2027-05-13 | 2027-05-19 | 25 | 45d | 0d |  |
| 27 | 1.3.7 | plancher bas rdc |  | 4d | 2027-05-20 | 2027-05-25 | 26 | 127d |  | start no earlier than 2026-05-04 |
| 28 | 1.3.8 | élévation RDC |  | 10d | 2027-05-20 | 2027-06-02 | 26 | 45d | 0d |  |
| 29 | 1.3.9 | plancher haut rdc |  | 5d | 2027-06-03 | 2027-06-09 | 28 | 45d | 0d |  |
| 30 | 1.3.10 | Couverture cuisine |  | 15d | 2027-06-10 | 2027-06-30 | 29 | 45d | 0d |  |
| 31 | 1.3.11 | Menuiseries éxtérieures extension |  | 5d | 2027-07-01 | 2027-07-07 | 30 | 45d | 0d |  |
| 32 | 1.3.12 | Cloisons sandwich | manual | 5d | 2027-07-01 | 2027-07-07 | 30 |  |  |  |
| 33 | 1.3.13 | CVC |  | 25d | 2027-06-10 | 2027-07-14 | 29 | 91d |  |  |

| ID | WBS | Task | Type | Duration | Start | Finish | Predecessors | Total slack | Free slack | Constraint |
| --- | --- | --- | --- | --- | --- | --- | --- | --- | --- | --- |
| 34 | 1.4 | **extension laverie** |  | 138d | 2027-03-29 | 2027-10-06 |  | 0d |  |  |
| 35 | 1.4.1 | Pieux laverie |  | 2d | 2027-03-29 | 2027-03-30 | 21 | 0d |  |  |
| 36 | 1.4.2 | réseaux sous plancher laverie |  | 5d | 2027-05-06 | 2027-05-12 | 24 | 0d |  |  |
| 37 | 1.4.3 | plancher laverie |  | 5d | 2027-05-13 | 2027-05-19 | 36 | 0d |  |  |
| 38 | 1.4.4 | élévation laverie compris monte charge |  | 10d | 2027-05-20 | 2027-06-02 | 37 | 0d |  |  |
| 39 | 1.4.5 | charpente laverie |  | 3d | 2027-06-03 | 2027-06-07 | 38 | 0d |  |  |
| 40 | 1.4.6 | Couverture étanchéité laverie |  | 10d | 2027-06-08 | 2027-09-29 | 39 | 0d |  |  |
| 41 | 1.4.7 | Cloisons sandwich | manual | 5d | 2027-09-30 | 2027-10-06 | 40 |  |  |  |
| 42 | 1.4.8 | Ascenseur |  | 10d | 2027-06-03 | 2027-06-16 | 38 | 111d |  |  |
| 43 | 1.5 | CVC |  | 15d | 2027-09-30 | 2027-10-20 | 40 | 0d |  |  |
| 44 | 1.6 | carrellage |  | 5d | 2027-09-30 | 2027-10-06 | 40 | 31d |  |  |
| 45 | 1.7 | **Travaux généraux** |  | 50d | 2027-06-10 | 2027-08-18 |  | 65d |  |  |
| 46 | 1.7.1 | Cloisons sandwich |  | 30d | 2027-06-10 | 2027-07-21 | 19 | 65d |  |  |
| 47 | 1.7.2 | équipement de cuisine |  | 30d | 2027-07-08 | 2027-08-18 | 31 | 45d |  |  |
| 48 | 1.7.3 | Travaux de façade |  | 30d | 2027-07-01 | 2027-08-11 | 30 | 71d |  |  |
| 49 | 1.8 | **Passerelle** |  | 193d | 2026-11-30 | 2027-09-10 |  | 49d |  |  |
| 50 | 1.8.1 | fondation passerelle |  | 10d | 2026-11-30 | 2026-12-11 |  | 49d | 0d | start no earlier than 2026-11-30 |
| 51 | 1.8.2 | ouverture et VRD paserelle |  | 20d | 2026-12-14 | 2027-01-26 | 50 | 49d | 0d |  |
| 52 | 1.8.3 | structure métallique paserelle |  | 45d | 2027-01-27 | 2027-09-10 | 51 | 49d |  |  |
| 53 | 1.9 | OPR |  | 10d | 2027-10-21 | 2027-11-03 | 47, 46, 43 | 0d |  |  |
| 54 | 1.10 | Reception |  | 1d | 2027-11-18 | 2027-11-18 | 53FS+10d | 0d |  |  |
